# 1Basics

Schedule from MS Project, 2017-01-23 to 2017-03-23, costs in $.

## Calendars

- Standard: Mon-Fri 08:00-12:00, 13:00-17:00; Sat-Sun off.

## Resources

| Resource | Group | Rate |
| --- | --- | --- |
| office manager | office staff | 40 |
| administrative assistant | office staff | 15 |
| editor |  | 20 |
| president | management | 38.46 |
| vice president |  | 30 |
| marketing vice president |  | 25 |
| chief financial officer | management | 33.65 |
| accounting assistant | management | 21.63 |
| layout coordinator | office staff | 12 |
| office temp | management | 43.27 |

## Schedule

| ID | WBS | Task | Type | Duration | Start | Finish | Predecessors | Total slack | Constraint | Resources | Work | Cost |
| --- | --- | --- | --- | --- | --- | --- | --- | --- | --- | --- | --- | --- |
| 1 | 1 | **Annual report** |  | 44d | 2017-01-23 | 2017-03-23 |  | 0d |  |  | 844.32h | 19,932.5 |
| 2 | 1.1 | **Initial planning** |  | 3d | 2017-01-23 | 2017-01-25 |  | 0d |  |  | 72h | 1,800 |
| 3 | 1.1.1 | Outline report articles |  | 3d | 2017-01-23 | 2017-01-25 |  | 0d |  | office manager; administrative assistant; editor | 72h | 1,800 |
| 4 | 1.2 | **Write management reports** |  | 25.5d | 2017-01-26 | 2017-03-02 | 3 | 0d |  |  | 600.32h | 14,031.88 |
| 5 | 1.2.1 | **Interview management** |  | 2d | 2017-01-26 | 2017-01-27 |  | 0d |  |  | 64h | 1,744.62 |
| 6 | 1.2.1.1 | President |  | 2d | 2017-01-26 | 2017-01-27 |  | 39d |  | editor; president | 32h | 935.38 |
| 7 | 1.2.1.2 | Vice President |  | 0.5d | 2017-01-26 | 2017-01-26 |  | 0d |  | editor; vice president | 8h | 200 |
| 8 | 1.2.1.3 | Marketing VP |  | 0.5d | 2017-01-26 | 2017-01-26 | 7 | 0d |  | editor; marketing vice president | 8h | 180 |
| 9 | 1.2.1.4 | Chief Financial Officer |  | 1d | 2017-01-27 | 2017-01-27 | 8 | 0d |  | chief financial officer; editor | 16h | 429.23 |
| 10 | 1.2.2 | **Assemble financial reports** |  | 14.25d | 2017-01-30 | 2017-02-17 | 9 | 0d |  |  | 384.32h | 7,767.27 |
| 11 | 1.2.2.1 | Gather financial data |  | 5.5d | 2017-01-30 | 2017-02-06 |  | 0d |  | accounting assistant [378%]; administrative assistant [200%] | 254.32h | 4,918.27 |
| 12 | 1.2.2.2 | Format reports |  | 2d | 2017-02-03 | 2017-02-07 | 11FS-1d | 0d |  | editor; layout coordinator | 32h | 512 |
| 13 | 1.2.2.3 | Compile data reference report |  | 0.5d | 2017-02-07 | 2017-02-07 | 12 | 0d |  | administrative assistant | 4h | 60 |
| 14 | 1.2.2.4 | Create graphics and charts |  | 3.25d | 2017-02-08 | 2017-02-17 | 13 | 0d |  | editor; office temp; layout coordinator | 78h | 1,957 |
| 15 | 1.2.2.5 | Review by CFO |  | 1w | 2017-02-08 | 2017-02-14 | 14SS | 0d |  |  |  |  |
| 16 | 1.2.2.6 | Edit |  | 2d | 2017-02-15 | 2017-02-16 | 15 | 0d |  | editor | 16h | 320 |
| 17 | 1.2.2.7 | Final approval | milestone | 0d | 2017-02-16 | 2017-02-16 | 16 | 0d |  |  |  |  |
| 18 | 1.2.3 | **Write articles** |  | 9.5d | 2017-02-17 | 2017-03-02 | 17 | 0d |  |  | 152h | 4,520 |
| 19 | 1.2.3.1 | Write first draft |  | 3d | 2017-02-17 | 2017-02-21 |  | 0d |  | editor; office manager | 48h | 1,440 |
| 20 | 1.2.3.2 | Management review |  | 1w | 2017-02-22 | 2017-02-28 | 19 | 0d |  | marketing vice president; office manager | 80h | 2,600 |
| 21 | 1.2.3.3 | Edit |  | 3d | 2017-02-27 | 2017-03-02 | 20FS-1.5d | 0d |  | editor | 24h | 480 |
| 22 | 1.2.3.4 | Final text approval | milestone | 0d | 2017-03-02 | 2017-03-02 | 21 | 0d |  |  |  |  |
| 23 | 1.3 | **Assemble final materials** |  | 8.5d | 2017-03-02 | 2017-03-14 | 22 | 0d |  |  | 132h | 2,596 |
| 24 | 1.3.1 | Final layout |  | 3d | 2017-03-02 | 2017-03-07 |  | 0d |  | administrative assistant; layout coordinator | 48h | 648 |
| 25 | 1.3.2 | Final proof |  | 3d | 2017-03-07 | 2017-03-10 | 24 | 0d | finish no earlier than 2014-01-21 | office manager; layout coordinator | 48h | 1,248 |
| 26 | 1.3.3 | Copy reports |  | 2.5d | 2017-03-10 | 2017-03-14 | 25 | 0d |  | administrative assistant | 20h | 300 |
| 27 | 1.3.4 | Write cover letter |  | 2d | 2017-03-13 | 2017-03-14 | 26FF | 0d |  | marketing vice president | 16h | 400 |

Notes:
- 14: Due to server problems there was a 1 day delay in work on graphics and charts.

| ID | WBS | Task | Type | Duration | Start | Finish | Predecessors | Total slack | Resources | Work | Cost |
| --- | --- | --- | --- | --- | --- | --- | --- | --- | --- | --- | --- |
| 28 | 1.4 | **Distribute reports** |  | 7d | 2017-03-15 | 2017-03-23 | 27 | 0d |  | 40h | 1,504.62 |
| 29 | 1.4.1 | Order envelopes/paper stock |  | 1d | 2017-03-15 | 2017-03-15 |  | 0d | administrative assistant | 8h | 120 |
| 30 | 1.4.2 | Print cover letters/envelopes |  | 2d | 2017-03-21 | 2017-03-22 | 29FS+3d | 0d | office temp | 16h | 692.31 |
| 31 | 1.4.3 | Stuff report packets |  | 1d | 2017-03-23 | 2017-03-23 | 30 | 0d | office temp [200%] | 16h | 692.31 |
| 32 | 1.4.4 | Report packets sent | milestone | 0d | 2017-03-23 | 2017-03-23 | 31 | 0d |  |  |  |
