# Office Remodel

Schedule from MS Project, 2017-10-09 to 2017-11-28.
Workspace
Paper Division

## Calendars

- Standard: Mon-Fri 08:00-12:00, 13:00-17:00; Sat-Sun off.
- Freight Elevator: Mon-Fri 16:00-20:00; Sat-Sun off.

## Resources

| Resource | Group |
| --- | --- |
| Administrative Assistant | management |
| Contractor | management |
| Janitor | office staff |
| Mover | management |
| Office Manager | outside service |
| Operations Manager | maintenance |
| Space Planner | contract |
| President | contract |

## Schedule

| ID | WBS | Task | Type | Duration | Start | Finish | Predecessors | Total slack | Free slack | Calendar | Resources | Work |
| --- | --- | --- | --- | --- | --- | --- | --- | --- | --- | --- | --- | --- |
| 1 | 1 | **Office Workspace Remodel** |  | 36.5d | 2017-10-09 | 2017-11-28 |  | 0d |  |  |  | 626h |
| 2 | 1.1 | **Space planning** |  | 12d | 2017-10-09 | 2017-10-24 |  | 0d |  |  |  | 256h |
| 3 | 1.1.1 | Interview space planners |  | 1w | 2017-10-09 | 2017-10-13 |  | 0d |  |  | Administrative Assistant; Mover; Contractor | 120h |
| 4 | 1.1.2 | Hire space planner |  | 2d | 2017-10-16 | 2017-10-17 | 3 | 0d |  |  | Administrative Assistant; Janitor | 32h |
| 5 | 1.1.3 | Meeting with space planner |  | 2d | 2017-10-18 | 2017-10-19 | 4 | 0d |  |  | Administrative Assistant; Contractor; Janitor; Mover; Office Manager | 80h |
| 6 | 1.1.4 | Finalize space plan |  | 3d | 2017-10-20 | 2017-10-24 | 5 | 0.88d | 0d |  | Office Manager | 24h |
| 7 | 1.1.5 | Space plan complete | milestone | 0d | 2017-10-24 | 2017-10-24 | 6 | 0.88d | 0d |  |  |  |
| 8 | 1.2 | **Furniture selection** |  | 15d | 2017-10-19 | 2017-11-08 |  | 13.5d |  |  |  | 90h |
| 9 | 1.2.1 | Preview furniture selections |  | 3d | 2017-10-19 | 2017-10-23 | 5SS+1d | 13.5d | 0d |  | Contractor; Mover; Janitor | 48h |
| 10 | 1.2.2 | Select new furniture |  | 2d | 2017-10-24 | 2017-10-25 | 9 | 13.5d | 0d |  | Contractor; Mover | 32h |
| 11 | 1.2.3 | Order new furniture |  | 0.5d | 2017-10-26 | 2017-10-26 | 10 | 13.5d | 0d |  | Janitor | 4h |
| 12 | 1.2.4 | Delivery time |  | 1.5w | 2017-10-26 | 2017-11-08 | 11 | 13.5d | 0d |  | Janitor [10%] | 6h |
| 13 | 1.2.5 | Furniture delivered | milestone | 0d | 2017-11-08 | 2017-11-08 | 12 | 13.5d |  |  |  |  |
| 14 | 1.3 | **Remodel workspace** |  | 14d | 2017-10-25 | 2017-11-13 |  | 0.88d | 0d |  |  | 144h |
| 15 | 1.3.1 | Hire contractor |  | 4d | 2017-10-25 | 2017-10-30 | 7 | 0.88d | 0d |  | Administrative Assistant; Mover | 64h |
| 16 | 1.3.2 | Remodel workspace |  | 2w | 2017-10-31 | 2017-11-13 | 15 | 0.88d | 0d |  | Space Planner | 80h |
| 17 | 1.3.3 | Remodel complete | milestone | 0d | 2017-11-13 | 2017-11-13 | 16 | 0.88d |  |  |  |  |
| 18 | 1.4 | **New workspace** |  | 10.5d | 2017-11-14 | 2017-11-28 | 14 | 0d |  |  |  | 136h |
| 19 | 1.4.1 | Hire mover |  | 2d | 2017-11-14 | 2017-11-15 |  | 0.88d | 0d |  | Contractor; Mover | 32h |
| 20 | 1.4.2 | Pack workspace |  | 1d | 2017-11-16 | 2017-11-16 | 19 | 0.88d | 0d |  | Mover; President | 16h |
| 21 | 1.4.3 | Move Equipment |  | 0.5d | 2017-11-16 | 2017-11-16 | 20FF | 0.88d | 0d |  | President; Mover | 8h |
| 22 | 1.4.4 | Remove existing furniture |  | 1d | 2017-11-16 | 2017-11-20 | 21 | 0.38d |  | Freight Elevator | President | 8h |
| 23 | 1.4.5 | Assemble new furniture |  | 2d | 2017-11-21 | 2017-11-22 | 22 | 0d |  |  | President; Office Manager | 32h |
| 24 | 1.4.6 | Return equipment |  | 1d | 2017-11-22 | 2017-11-23 | 23FS-0.5d | 0d |  |  | President; Mover | 16h |
| 25 | 1.4.7 | Unpack workspace |  | 1.5d | 2017-11-23 | 2017-11-27 | 24 | 0d |  |  | President; Janitor | 16h |
| 26 | 1.4.8 | Workspace final clean |  | 1d | 2017-11-27 | 2017-11-28 | 25 | 0d |  |  | Janitor | 8h |
| 27 | 1.5 | Workspace remodel complete | milestone | 0d | 2017-11-28 | 2017-11-28 | 18 | 0d |  |  |  |  |
