# Office Remodel

Schedule from MS Project, 2017-10-09 to 2017-11-27, costs in $.
Workspace
Paper Division

## Calendars

- Standard: Mon-Fri 08:00-12:00, 13:00-17:00; Sat-Sun off.
- Freight Elevator: Mon-Fri 16:00-20:00; Sat-Sun off.

## Resources

| Resource | Group | Rate | Notes |
| --- | --- | --- | --- |
| president | management |  |  |
| office manager | management |  |  |
| administrative assistant | office staff | 20 |  |
| operations manager | management | 28.85 |  |
| space planner | outside service |  |  |
| janitor | maintenance | 16 | The cost rate table B is for construction cleaning tasks. |
| contractor | contract |  |  |
| mover | contract |  |  |

## Schedule

| ID | WBS | Task | Type | Duration | Start | Finish | Predecessors | Total slack | Free slack | Calendar | Resources | Work | Cost |
| --- | --- | --- | --- | --- | --- | --- | --- | --- | --- | --- | --- | --- | --- |
| 1 | 1 | **Office Workspace Remodel** |  | 36d | 2017-10-09 | 2017-11-27 |  | 0d |  |  |  | 626h | 18,872 |
| 2 | 1.1 | **Space planning** |  | 12d | 2017-10-09 | 2017-10-24 |  | 0.88d |  |  |  | 256h | 2,384.62 |
| 3 | 1.1.1 | Interview space planners |  | 1w | 2017-10-09 | 2017-10-13 |  | 0.88d | 0d |  | president; operations manager; office manager | 120h | 1,246.15 |
| 4 | 1.1.2 | Hire space planner |  | 2d | 2017-10-16 | 2017-10-17 | 3 | 0.88d | 0d |  | president; administrative assistant | 32h | 320 |
| 5 | 1.1.3 | Meeting with space planner |  | 2d | 2017-10-18 | 2017-10-19 | 4 | 0.88d | 0d |  | president; office manager; administrative assistant; operations manager; space planner | 80h | 818.46 |
| 6 | 1.1.4 | Finalize space plan |  | 3d | 2017-10-20 | 2017-10-24 | 5 | 0.88d | 0d |  | space planner | 24h |  |
| 7 | 1.1.5 | Space plan complete | milestone | 0d | 2017-10-24 | 2017-10-24 | 6 | 0.88d | 0d |  |  |  |  |
| 8 | 1.2 | **Furniture selection** |  | 12d | 2017-10-19 | 2017-11-03 |  | 16d |  |  |  | 90h | 1,516.92 |
| 9 | 1.2.1 | Preview furniture selections |  | 2d | 2017-10-19 | 2017-10-20 | 5SS+1d | 16d | 0d |  | office manager; operations manager; administrative assistant | 48h | 818.46 |
| 10 | 1.2.2 | Select new furniture |  | 2d | 2017-10-23 | 2017-10-24 | 9 | 16d | 0d |  | office manager; operations manager | 32h | 498.46 |
| 11 | 1.2.3 | Order new furniture |  | 0.5d | 2017-10-25 | 2017-10-25 | 10 | 16d | 0d |  | administrative assistant | 4h | 80 |
| 12 | 1.2.4 | Delivery time |  | 1.5w | 2017-10-25 | 2017-11-03 | 11 | 16d | 0d |  | administrative assistant [10%] | 6h | 120 |
| 13 | 1.2.5 | Furniture delivered | milestone | 0d | 2017-11-03 | 2017-11-03 | 12 | 16d |  |  |  |  |  |
| 14 | 1.3 | **Remodel workspace** |  | 14d | 2017-10-25 | 2017-11-13 |  | 0.88d | 0d |  |  | 144h | 13,496.92 |
| 15 | 1.3.1 | Hire contractor |  | 4d | 2017-10-25 | 2017-10-30 | 7 | 0.88d | 0d |  | president; operations manager | 64h | 996.92 |
| 16 | 1.3.2 | Remodel workspace |  | 2w | 2017-10-31 | 2017-11-13 | 15 | 0.88d | 0d |  | contractor | 80h | 12,500 |
| 17 | 1.3.3 | Remodel complete | milestone | 0d | 2017-11-13 | 2017-11-13 | 16 | 0.88d |  |  |  |  |  |
| 18 | 1.4 | **New workspace** |  | 10d | 2017-11-14 | 2017-11-27 | 14 | 0d |  |  |  | 136h | 1,473.54 |
| 19 | 1.4.1 | Hire mover |  | 2d | 2017-11-14 | 2017-11-15 |  | 0.88d | 0d |  | office manager; operations manager | 32h | 498.46 |
| 20 | 1.4.2 | Pack workspace |  | 1d | 2017-11-16 | 2017-11-16 | 19 | 0.88d | 0d |  | operations manager; mover | 16h | 249.23 |
| 21 | 1.4.3 | Move Equipment |  | 0.5d | 2017-11-16 | 2017-11-16 | 20FF | 0.88d | 0d |  | mover; operations manager | 8h | 124.62 |
| 22 | 1.4.4 | Remove existing furniture |  | 1d | 2017-11-16 | 2017-11-20 | 21 | 0.38d |  | Freight Elevator | mover | 8h |  |
| 23 | 1.4.5 | Assemble new furniture |  | 2d | 2017-11-21 | 2017-11-22 | 22 | 0.5d | 0d |  | mover; space planner | 32h |  |
| 24 | 1.4.6 | Return equipment |  | 1d | 2017-11-22 | 2017-11-23 | 23FS-0.5d | 0.5d | 0d |  | mover; operations manager | 16h | 249.23 |
| 25 | 1.4.7 | Unpack workspace |  | 1d | 2017-11-23 | 2017-11-24 | 24 | 0.5d |  |  | mover; administrative assistant | 16h | 160 |
| 26 | 1.4.8 | Workspace final clean |  | 1d | 2017-11-27 | 2017-11-27 | 25 | 0d |  |  | janitor | 8h | 192 |
| 27 | 1.5 | Workspace remodel complete | milestone | 0d | 2017-11-27 | 2017-11-27 | 18 | 0d |  |  |  |  |  |
