# Office Remodel

Schedule from MS Project, 2017-10-09 to 2017-11-24, status date 2017-11-06, costs in $, A marks actual dates.
Workspace
Paper Division

## Calendars

- Standard: Mon-Fri 08:00-12:00, 13:00-17:00; Sat-Sun off.
- Freight Elevator: Mon-Fri 16:00-20:00; Sat-Sun off.

## Resources

| Resource | Group | Rate |
| --- | --- | --- |
| President | contract | 38.46 |
| Office Manager | outside service | 25 |
| Administrative Assistant | management | 20 |
| Operations Manager | management | 31.15 |
| Space Planner | contract | 40 |
| Janitor | office staff | 16 |
| Contractor | management |  |
| Mover | management | 25 |

## Schedule

| ID | WBS | Task | Type | Duration | Start | Finish | Predecessors | Complete | Remaining | Baseline start | Baseline finish | Baseline duration | Total slack | Free slack | Constraint | Deadline | Calendar | Resources | Work | Actual work | Cost | Baseline cost | Actual cost |
| --- | --- | --- | --- | --- | --- | --- | --- | --- | --- | --- | --- | --- | --- | --- | --- | --- | --- | --- | --- | --- | --- | --- | --- |
| 1 | 1 | **Office Workspace Remodel** |  | 34d | 2017-10-09 A | 2017-11-24 |  | 74% | 8.99d | 2017-10-09 | 2017-11-24 | 34d | 0d |  |  |  |  |  | 608h | 481.6h | 27,382.77 | 27,382.77 | 24,004.31 |
| 2 | 1.1 | **Space planning** |  | 13d | 2017-10-09 A | 2017-10-25 A |  | 100% |  | 2017-10-09 | 2017-10-25 | 13d |  |  |  |  |  |  | 222h | 222h | 6,846.15 | 6,846.15 | 6,846.15 |
| 3 | 1.1.1 | Interview space planners |  | 1w | 2017-10-09 A | 2017-10-13 A |  | 100% |  | 2017-10-09 | 2017-10-13 | 1w |  |  |  |  |  | Operations Manager; Office Manager; President [25%] | 86h | 86h | 2,476.92 | 2,476.92 | 2,476.92 |
| 4 | 1.1.2 | Hire space planner |  | 2d | 2017-10-16 A | 2017-10-17 A | 3 | 100% |  | 2017-10-16 | 2017-10-17 | 2d |  |  |  |  |  | President; Administrative Assistant | 32h | 32h | 935.38 | 935.38 | 935.38 |
| 5 | 1.1.3 | Meeting with space planner |  | 2d | 2017-10-18 A | 2017-10-19 A | 4 | 100% |  | 2017-10-18 | 2017-10-19 | 2d |  |  |  |  |  | President; Office Manager; Administrative Assistant; Operations Manager; Space Planner | 80h | 80h | 2,473.85 | 2,473.85 | 2,473.85 |
| 6 | 1.1.4 | Finalize space plan |  | 3d | 2017-10-23 A | 2017-10-25 A | 5 | 100% |  | 2017-10-23 | 2017-10-25 | 3d |  |  |  | 2017-10-25 |  | Space Planner | 24h | 24h | 960 | 960 | 960 |
| 7 | 1.1.5 | Space plan complete | milestone | 0d | 2017-10-25 A | 2017-10-25 A | 6 | 100% |  | 2017-10-25 | 2017-10-25 | 0d |  |  |  |  |  |  |  |  |  |  |  |
| 8 | 1.2 | **Furniture selection** |  | 13d | 2017-10-24 A | 2017-11-09 |  | 79% | 2.79d | 2017-10-24 | 2017-11-09 | 13d | 10d |  |  |  |  |  | 90h | 87.6h | 1,680 | 1,680 | 1,632 |
| 9 | 1.2.1 | Preview furniture selections |  | 4d | 2017-10-24 A | 2017-10-27 A | 5SS+1d | 100% |  | 2017-10-24 | 2017-10-27 | 4d |  |  |  |  |  | Office Manager; Administrative Assistant | 64h | 64h | 1,080 | 1,080 | 1,080 |
| 10 | 1.2.2 | Select new furniture |  | 2d | 2017-10-30 A | 2017-10-31 A | 9 | 100% |  | 2017-10-30 | 2017-10-31 | 2d |  |  |  |  |  | Office Manager | 16h | 16h | 400 | 400 | 400 |
| 11 | 1.2.3 | Order new furniture |  | 0.5d | 2017-10-31 A | 2017-10-31 A | 10 | 100% |  | 2017-10-31 | 2017-10-31 | 0.5d |  |  |  |  |  | Administrative Assistant | 4h | 4h | 80 | 80 | 80 |
| 12 | 1.2.4 | Delivery time |  | 1.5w | 2017-10-31 A | 2017-11-09 | 11 | 60% | 0.6w | 2017-10-31 | 2017-11-09 | 1.5w | 10d | 0d | finish no earlier than 2013-11-03 |  |  | Administrative Assistant [10%] | 6h | 3.6h | 120 | 120 | 72 |
| 13 | 1.2.5 | Furniture delivered | milestone | 0d | 2017-11-09 | 2017-11-09 | 12 |  |  | 2017-11-09 | 2017-11-09 | 0d | 10d |  |  |  |  |  |  |  |  |  |  |
| 14 | 1.3 | **Remodel workspace** |  | 9d | 2017-10-25 A | 2017-11-07 A |  | 100% |  | 2017-10-25 | 2017-11-07 | 9d |  |  |  |  |  |  | 144h | 144h | 14,727.69 | 14,727.69 | 14,727.69 |
| 15 | 1.3.1 | Hire contractor |  | 4d | 2017-10-25 A | 2017-10-30 A | 7 | 100% |  | 2017-10-25 | 2017-10-30 | 4d |  |  |  |  |  | President; Operations Manager | 64h | 64h | 2,227.69 | 2,227.69 | 2,227.69 |
| 16 | 1.3.2 | Remodel workspace |  | 1w | 2017-10-31 A | 2017-11-06 A | 15 | 100% |  | 2017-10-31 | 2017-11-06 | 1w |  |  |  |  |  | Contractor [200%] | 80h | 80h | 12,500 | 12,500 | 12,500 |
| 17 | 1.3.3 | Remodel complete | milestone | 0d | 2017-11-07 A | 2017-11-07 A | 16 | 100% |  | 2017-11-07 | 2017-11-07 | 0d |  |  |  |  |  |  |  |  |  |  |  |
| 18 | 1.4 | **New workspace** |  | 12.5d | 2017-11-07 A | 2017-11-23 | 14 | 17% | 10.42d | 2017-11-07 | 2017-11-23 | 12.5d | 0.5d |  |  |  |  |  | 152h | 28h | 4,128.92 | 4,128.92 | 798.46 |
| 19 | 1.4.1 | Hire mover |  | 2d | 2017-11-07 A | 2017-11-08 | 15SS | 75% | 0.5d | 2017-11-07 | 2017-11-08 | 2d | 2.33d | 2d |  |  |  | Office Manager; Operations Manager | 32h | 24h | 898.46 | 898.46 | 673.85 |
| 20 | 1.4.2 | Pack workspace |  | 1.5d | 2017-11-13 A | 2017-11-14 | 19, 15 | 22% | 1.17d | 2017-11-13 | 2017-11-14 | 1.5d | -1.62d | 0d |  |  |  | Operations Manager; Janitor | 16h | 4h | 377.23 | 377.23 | 124.62 |
| 21 | 1.4.3 | Move Equipment |  | 0.5d | 2017-11-14 | 2017-11-14 | 20FF |  |  | 2017-11-14 | 2017-11-14 | 0.5d | -1.62d | 0d |  |  |  | Mover; Office Manager | 8h |  | 200 | 200 |  |
| 22 | 1.4.4 | Remove existing furniture |  | 1d | 2017-11-14 | 2017-11-15 | 21 |  |  | 2017-11-14 | 2017-11-15 | 1d | -1d | 0d |  |  | Freight Elevator | Mover | 8h |  | 200 | 200 |  |
| 23 | 1.4.5 | Assemble new furniture |  | 2d | 2017-11-16 | 2017-11-17 | 22, 16 |  |  | 2017-11-16 | 2017-11-17 | 2d | -2d | 0d |  | 2017-11-15 |  | Office Manager; Space Planner [125%] | 32h |  | 1,120 | 1,120 |  |
| 24 | 1.4.6 | Return equipment |  | 1d | 2017-11-17 | 2017-11-20 | 23FS-0.5d |  |  | 2017-11-17 | 2017-11-20 | 1d | 0.5d | 0d |  |  |  | Mover; Operations Manager | 16h |  | 449.23 | 449.23 |  |
| 25 | 1.4.7 | Unpack workspace |  | 2d | 2017-11-20 | 2017-11-22 | 24 |  |  | 2017-11-20 | 2017-11-22 | 2d | 0.5d | 0d |  |  |  | Mover; Administrative Assistant | 32h |  | 720 | 720 |  |
| 26 | 1.4.8 | Workspace final clean |  | 1d | 2017-11-22 | 2017-11-23 | 25 |  |  | 2017-11-22 | 2017-11-23 | 1d | 0.5d |  |  |  |  | Janitor [50%]; Mover [50%] | 8h |  | 164 | 164 |  |
| 27 | 1.5 | Workspace remodel complete | milestone | 0d | 2017-11-24 | 2017-11-24 | 26 |  |  | 2017-11-24 | 2017-11-24 | 0d | 0d |  | must finish on 2017-11-24 |  |  |  |  |  |  |  |  |
