# Office Remodel

Schedule from MS Project, 2017-10-09 to 2017-11-22, costs in $.
Workspace
Paper Division

## Calendars

- Standard: Mon-Fri 08:00-12:00, 13:00-17:00; Sat-Sun off.
- Freight Elevator: Mon-Fri 16:00-20:00; Sat-Sun off.

## Resources

| Resource | Group | Rate |
| --- | --- | --- |
| President | contract | 38.46 |
| Office Manager | outside service | 25 |
| Administrative Assistant | management | 20 |
| Operations Manager | management | 31.15 |
| Space Planner | contract | 40 |
| Janitor | office staff | 16 |
| Contractor | management |  |
| Mover | management | 25 |

## Schedule

| ID | WBS | Task | Type | Duration | Start | Finish | Predecessors | Baseline start | Baseline finish | Baseline duration | Total slack | Free slack | Constraint | Deadline | Calendar | Resources | Work | Cost | Baseline cost |
| --- | --- | --- | --- | --- | --- | --- | --- | --- | --- | --- | --- | --- | --- | --- | --- | --- | --- | --- | --- |
| 1 | 1 | **Office Workspace Remodel** |  | 32d | 2017-10-09 | 2017-11-22 |  | 2013-10-07 | 2013-11-20 | 32d | 0d |  |  |  |  |  | 584h | 27,182.77 | 27,182.77 |
| 2 | 1.1 | **Space planning** |  | 12d | 2017-10-09 | 2017-10-24 |  | 2013-10-07 | 2013-10-22 | 12d | 0d |  |  |  |  |  | 222h | 6,846.15 | 6,846.15 |
| 3 | 1.1.1 | Interview space planners |  | 1w | 2017-10-09 | 2017-10-13 |  | 2013-10-07 | 2013-10-11 | 1w | 0d |  |  |  |  | Operations Manager; Office Manager; President [25%] | 86h | 2,476.92 | 2,476.92 |
| 4 | 1.1.2 | Hire space planner |  | 2d | 2017-10-16 | 2017-10-17 | 3 | 2013-10-14 | 2013-10-15 | 2d | 0d |  |  |  |  | President; Administrative Assistant | 32h | 935.38 | 935.38 |
| 5 | 1.1.3 | Meeting with space planner |  | 2d | 2017-10-18 | 2017-10-19 | 4 | 2013-10-16 | 2013-10-17 | 2d | 0d |  |  |  |  | President; Office Manager; Administrative Assistant; Operations Manager; Space Planner | 80h | 2,473.85 | 2,473.85 |
| 6 | 1.1.4 | Finalize space plan |  | 3d | 2017-10-20 | 2017-10-24 | 5 | 2013-10-18 | 2013-10-22 | 3d | 0d |  |  | 2017-10-25 |  | Space Planner | 24h | 960 | 960 |
| 7 | 1.1.5 | Space plan complete | milestone | 0d | 2017-10-24 | 2017-10-24 | 6 | 2013-10-22 | 2013-10-22 | 0d | 0d |  |  |  |  |  |  |  |  |
| 8 | 1.2 | **Furniture selection** |  | 12d | 2017-10-23 | 2017-11-07 |  | 2013-10-21 | 2013-11-05 | 12d | 10d |  |  |  |  |  | 66h | 1,480 | 1,480 |
| 9 | 1.2.1 | Preview furniture selections |  | 3d | 2017-10-23 | 2017-10-25 | 5SS+1d | 2013-10-21 | 2013-10-23 | 3d | 10d | 0d |  |  |  | Office Manager; Administrative Assistant | 48h | 1,080 | 1,080 |
| 10 | 1.2.2 | Select new furniture |  | 1d | 2017-10-26 | 2017-10-26 | 9 | 2013-10-24 | 2013-10-24 | 1d | 10d | 0d |  |  |  | Office Manager | 8h | 200 | 200 |
| 11 | 1.2.3 | Order new furniture |  | 0.5d | 2017-10-27 | 2017-10-27 | 10 | 2013-10-25 | 2013-10-25 | 0.5d | 10d | 0d |  |  |  | Administrative Assistant | 4h | 80 | 80 |
| 12 | 1.2.4 | Delivery time |  | 1.5w | 2017-10-27 | 2017-11-07 | 11 | 2013-10-25 | 2013-11-05 | 1.5w | 10d | 0d | finish no earlier than 2013-11-03 |  |  | Administrative Assistant [10%] | 6h | 120 | 120 |
| 13 | 1.2.5 | Furniture delivered | milestone | 0d | 2017-11-07 | 2017-11-07 | 12 | 2013-11-05 | 2013-11-05 | 0d | 10d |  |  |  |  |  |  |  |  |
| 14 | 1.3 | **Remodel workspace** |  | 9d | 2017-10-25 | 2017-11-06 |  | 2013-10-23 | 2013-11-04 | 9d | 0d |  |  |  |  |  | 144h | 14,727.69 | 14,727.69 |
| 15 | 1.3.1 | Hire contractor |  | 4d | 2017-10-25 | 2017-10-30 | 7 | 2013-10-23 | 2013-10-28 | 4d | 0d |  |  |  |  | President; Operations Manager | 64h | 2,227.69 | 2,227.69 |
| 16 | 1.3.2 | Remodel workspace |  | 1w | 2017-10-31 | 2017-11-06 | 15 | 2013-10-29 | 2013-11-04 | 1w | 0d |  |  |  |  | Contractor [200%] | 80h | 12,500 | 12,500 |
| 17 | 1.3.3 | Remodel complete | milestone | 0d | 2017-11-06 | 2017-11-06 | 16 | 2013-11-04 | 2013-11-04 | 0d | 0d |  |  |  |  |  |  |  |  |
| 18 | 1.4 | **New workspace** |  | 10.5d | 2017-11-07 | 2017-11-21 | 14 | 2013-11-05 | 2013-11-19 | 10.5d | 0d |  |  |  |  |  | 152h | 4,128.92 | 4,128.92 |
| 19 | 1.4.1 | Hire mover |  | 2d | 2017-11-07 | 2017-11-08 | 15SS | 2013-11-05 | 2013-11-06 | 2d | 0d |  |  |  |  | Office Manager; Operations Manager | 32h | 898.46 | 898.46 |
| 20 | 1.4.2 | Pack workspace |  | 1d | 2017-11-09 | 2017-11-09 | 19, 15 | 2013-11-07 | 2013-11-07 | 1d | 0d |  |  |  |  | Operations Manager; Janitor | 16h | 377.23 | 377.23 |
| 21 | 1.4.3 | Move Equipment |  | 0.5d | 2017-11-09 | 2017-11-09 | 20FF | 2013-11-07 | 2013-11-07 | 0.5d | 0.88d | 0d |  |  |  | Mover; Office Manager | 8h | 200 | 200 |
| 22 | 1.4.4 | Remove existing furniture |  | 1d | 2017-11-09 | 2017-11-13 | 21 | 2013-11-07 | 2013-11-11 | 1d | 0.38d |  |  |  | Freight Elevator | Mover | 8h | 200 | 200 |
| 23 | 1.4.5 | Assemble new furniture |  | 2d | 2017-11-14 | 2017-11-15 | 22, 16 | 2013-11-12 | 2013-11-13 | 2d | 0d |  |  | 2017-11-15 |  | Office Manager; Space Planner [125%] | 32h | 1,120 | 1,120 |
| 24 | 1.4.6 | Return equipment |  | 1d | 2017-11-15 | 2017-11-16 | 23FS-0.5d | 2013-11-13 | 2013-11-14 | 1d | 0.5d | 0d |  |  |  | Mover; Operations Manager | 16h | 449.23 | 449.23 |
| 25 | 1.4.7 | Unpack workspace |  | 2d | 2017-11-16 | 2017-11-20 | 24 | 2013-11-14 | 2013-11-18 | 2d | 0.5d | 0d |  |  |  | Mover; Administrative Assistant | 32h | 720 | 720 |
| 26 | 1.4.8 | Workspace final clean |  | 1d | 2017-11-20 | 2017-11-21 | 25 | 2013-11-18 | 2013-11-19 | 1d | 0.5d |  |  |  |  | Janitor [50%]; Mover [50%] | 8h | 164 | 164 |
| 27 | 1.5 | Workspace remodel complete | milestone | 0d | 2017-11-22 | 2017-11-22 | 26 | 2013-11-20 | 2013-11-20 | 0d | 0d |  | must finish on 2017-11-22 |  |  |  |  |  |  |
